# AL-04 - bronbemaling+heiwerk

Schedule from MS Project, 2003-01-12 to 2003-02-15, status date 2003-01-08.
BAM Nelissen Van Egteren

## Calendars

- ALLEEN WERKDAGEN: Mon-Fri 08:30-12:30, 13:00-17:00; Sat-Sun off. Exceptions (off unless hours are given): 2003-01-11 to 2003-01-12 08:30-12:30, 13:00-17:00, 2003-01-18 to 2003-01-19 08:30-12:30, 13:00-17:00, 2003-01-25 to 2003-01-26 08:30-12:30, 13:00-17:00, 2003-02-01 to 2003-02-02 08:30-12:30, 13:00-17:00, 2003-02-08 to 2003-02-09 08:30-12:30, 13:00-17:00, 2003-02-15 to 2003-02-16 08:30-12:30, 13:00-17:00.

## Schedule

| ID | WBS | Task | Type | Duration | Start | Finish | Predecessors | Total slack |
| --- | --- | --- | --- | --- | --- | --- | --- | --- |
| 1 | 1 | **AANLOOPFASE** |  | 35d | 2003-01-12 | 2003-02-15 |  | 0d |
| 2 | 1.1 | keten/loodsen/afrastering |  | 10d | 2003-01-12 | 2003-01-21 |  | 0d |
| 3 | 1.2 | bouwinstallatie aanleggen |  | 10d | 2003-01-12 | 2003-01-21 | 2SS | 0d |
| 4 | 1.3 | bouwwegen aanleggen |  | 9d | 2003-01-14 | 2003-01-22 | 3SS+2d | 0d |
| 5 | 1.4 | uitzetten + bouwplanken |  | 5d | 2003-01-17 | 2003-01-21 | 4SS+3d | 0d |
| 6 | 1.5 | bronbemaling installeren |  | 5d | 2003-01-19 | 2003-01-23 | 5SS+2d | 0d |
| 7 | 1.6 | bouwput ontgraven |  | 5d | 2003-01-24 | 2003-01-28 | 6SS+5d | 0d |
| 8 | 1.7 | heipikketten uitzetten |  | 2d | 2003-01-29 | 2003-01-30 | 7SS+5d | 0d |
| 9 | 1.8 | betonpalen heien |  | 8d | 2003-01-31 | 2003-02-07 | 8SS+2d | 0d |
| 10 | 1.9 | paalkoppen snellen |  | 2d | 2003-02-08 | 2003-02-09 | 9SS+8d | 0d |
| 11 | 1.10 | paalkoppen afvoeren |  | 3d | 2003-02-10 | 2003-02-12 | 10SS+2d | 0d |
| 12 | 1.11 | liftput+poeren ontgraven |  | 2d | 2003-02-12 | 2003-02-13 | 11SS+2d | 0d |
| 13 | 1.12 | maatvoeren funderingsbalken |  | 1d | 2003-02-14 | 2003-02-14 | 12SS+2d | 0d |
| 14 | 1.13 | start onderbouw | milestone | 0d | 2003-02-15 | 2003-02-15 | 13SS+2d | 0d |
